# CRONOGRAMA FÍSICO E FINANCEIRO - REFORMA REV 2

Schedule from MS Project, 2021-08-02 to 2022-09-28, costs in R$.

## Calendars

- Padrão: Mon-Fri 09:00-12:00, 13:00-18:00; Sat-Sun off.

## Schedule

| ID | WBS | Task | Duration | Start | Finish | Predecessors | Total slack | Free slack | Constraint | Cost |
| --- | --- | --- | --- | --- | --- | --- | --- | --- | --- | --- |
| 1 | 1 | **REFORMA** | 303d | 2021-08-02 | 2022-09-28 |  | 0d |  |  | 2,738,854.04 |
| 2 | 1.1 | **DEMOLIR** | 8d | 2021-08-02 | 2021-08-11 |  | 203d |  |  | 27,737.37 |
| 3 | 1.1.1 | DEMOLICAO MANUAL DE ALVENARIA DE TIJOLOS FURADOS,INCLUSIVE EMPILHAMENTO LATERAL DENTRO DO CANTEIRO DE SERVICO | 3d | 2021-08-02 | 2021-08-04 |  | 219d | 0d |  | 3,068.48 |
| 4 | 1.1.2 | TRANSPORTE DE CARGA DE QUALQUER NATUREZA,EXCLUSIVE AS DESPESAS DE CARGA E DESCARGA,TANTO DE ESPERA DO CAMINHAO COMO DO SERVENTE OU EQUIPAMENTO AUXILIAR,A VELOCIDADE MEDIA DE 20KM/H,EM CAMINHAO BASCULANTE A OLEO DIESEL,COM CAPACIDADE UTIL DE8T | 2d | 2021-08-04 | 2021-08-05 | 3FS-1d | 299d |  |  | 2,866.64 |
| 5 | 1.1.3 | CARGA E DESCARGA MECANICA,COM PA-CARREGADEIRA,COM 1,30M3 DE CAPACIDADE,UTILIZANDO CAMINHAO BASCULANTE A OLEO DIESEL,COMCAPACIDADE UTIL DE 8T,CONSIDERADOS PARA O CAMINHAO OS TEMPOSDE ESPERA,MANOBRA,CARGA E DESCARGA E PARA A CARREGADEIRA OSTEMPOS DE ESPERA | 2d | 2021-08-05 | 2021-08-06 | 3 | 219d | 0d |  | 4,171.77 |
| 6 | 1.1.4 | Disposição final de materiais e resíduos de obras em locais de operação e disposição final apropriados, autorizados e/ou licenciados pelos órgãos de licenciamento e de controle ambiental, medida por tonelada transportada, sendo comprovada conforme legisla | 1d | 2021-08-06 | 2021-08-06 | 5FS-1d | 219d | 0d |  | 773.06 |
| 7 | 1.1.5 | Remoção de árvore de grande porte, compreendendo a poda com o emprego de Caminhão de Carroceria Fixa, elevador equipado com caçamba atingindo altura média de 15m, moto serra, escada, corda, serrote, machados, sinalização de desvio de tráfego de veículos, | 2d | 2021-08-09 | 2021-08-10 | 6 | 296d |  |  | 11,361.44 |
| 8 | 1.1.6 | Destocamento de árvores de grande porte acima de 61cm DAP e raízes profundas, com auxílio mecânico, inclusive carga, descarga e transporte do material resultante até 30Km. | 3d | 2021-08-09 | 2021-08-11 | 6 | 219d | 0d |  | 5,495.98 |
| 9 | 1.2 | **ALVENARIA** | 15d | 2021-09-09 | 2021-09-29 |  | 180d |  |  | 89,971.55 |
| 10 | 1.2.1 | ALVENARIA DE TIJOLOS CERAMICOS FURADOS 10X20X20CM,ASSENTES COM ARGAMASSA DE CIMENTO E SAIBRO,NO TRACO 1:8,EM PAREDES DEUMA VEZ(0,20M),DE SUPERFICIE CORRIDA,ATE 3,00M DE ALTURA E MEDIDA PELA AREA REAL | 15d | 2021-09-09 | 2021-09-29 | 6 | 180d | 0d | finish no earlier than 2021-09-29 | 79,835.14 |
| 11 | 1.2.2 | CARGA E DESCARGA MANUAL DE PECAS DE PESO REDUZIDO:TIJOLOS,TELHAS,CIMENT O E AGREGADOS EM SACOS,EM CAMINHAO DE CARROCERIAFIXA A OLEO DIESEL,COM CAPACIDADE UTIL DE 7,5T,INCLUSIVE O TEMPO DE CARGA,DESCARGA E MANOBRA | 4d | 2021-09-09 | 2021-09-14 | 10SS | 271d |  | start no earlier than 2021-08-19 | 10,136.41 |
| 12 | 1.3 | **EMBOÇO INTERNO E EXTERNO** | 35d | 2021-10-11 | 2021-11-26 |  | 173d |  |  | 107,127.3 |
| 13 | 1.3.1 | EMBOCO INTERNO COM ARGAMASSA DE CIMENTO E SAIBRO,NO TRACO 1:6,COM 2,5CM DE ESPESSURA,INCLUSIVE CHAPISCO DE CIMENTO E AREIA,NO TRACO 1:3 | 30d | 2021-10-11 | 2021-11-19 | 10 | 208d | 43d | start no earlier than 2021-10-11 | 58,938.54 |
| 14 | 1.3.2 | REVESTIMENTO EXTERNO,DE UMA VEZ,COM ARGAMASSA DE CIMENTO E AREOLA PARA EMBOCO,NO TRACO 1:2,COM 3CM DE ESPESSURA,INCLUSIVE CHAPISCO DE CIMENTO E AREIA,NO TRACO 1:3 | 30d | 2021-10-18 | 2021-11-26 | 10 | 168d | 150d | start no earlier than 2021-10-18 | 48,188.76 |
| 15 | 1.4 | **IMPERMEABILIZAÇÃO** | 30d | 2021-10-28 | 2021-12-08 |  | 210d |  |  | 66,714.85 |
| 16 | 1.4.1 | IMPERMEABILIZACAO/REVESTIMENTO DE PISOS,COM ELASTOMERO A BASE DE POLIUREIA,ISENTO DE SOLVENTES,MOLDADO NO LOCAL,CURA LENTA,A FRIO,APLICADO COM EQUIPAMENTO TIPO AIRLESS,ROLO OU PINCEL,COM 1,20MM DE ESPESSURA,ANTIDERRAPANTE,SEM PROTECAO MECANICA | 10d | 2021-10-28 | 2021-11-10 | 21 | 230d |  | finish no earlier than 2021-11-10 | 7,029.72 |
| 17 | 1.4.2 | IMPERMEABILIZACAO/REVESTIMENTO DE LAJES,TANQUES,PISCINAS,RESERVA TORIOS,ARQUIBANCADAS,ESTACIONA MENTOS,COM ELASTOMERO A BASE DE POLIUREIA,ISENTO DE SOLVENTES,MOLDADO NO LOCAL,CURA LENTA,A FRIO,APLICADO COM EQUIPAMENTO TIPO AIRLESS,ROLO OU PINCEL,COM 2,00M | 30d | 2021-10-28 | 2021-12-08 | 21 | 210d |  | finish no earlier than 2021-12-08 | 59,685.13 |
| 18 | 1.5 | **ACABAMENTOS INTERNOS** | 277d | 2021-08-12 | 2022-09-02 |  | 18d |  |  | 465,289.78 |
| 19 | 1.5.1 | **PISOS** | 102d | 2021-10-14 | 2022-03-04 |  | 148d |  |  | 121,187.7 |
| 20 | 1.5.1.1 | PORCELANATO TÉCNICO RETIFICADO 90X90 - NATURAL | 15d | 2022-02-10 | 2022-03-02 | 21 | 115d | 0d | finish no earlier than 2022-03-02 | 98,158.68 |
| 21 | 1.5.1.2 | CONTRAPISO,BASE OU CAMADA REGULARIZADORA,EXECUTADA COM ARGAMASSA DE CIMENTO E AREIA,NO TRACO 1:4,NA ESPESSURA DE 3,5CM | 10d | 2021-10-14 | 2021-10-27 | 25 | 190d | 0d | finish no earlier than 2021-10-27 | 21,280.66 |
| 22 | 1.5.1.3 | CHAPIM/SOLEIRA DE CONCRETO APARENTE COM ACABAMENTO DESEMPENADO,USANDO FORMA DE CHAPA COMPENSADA,MEDINDO 14X10CM,CONFORMEPROJETO TIPO N§6062/EMOP,FUNDIDO NO LOCAL | 2d | 2022-03-03 | 2022-03-04 |  | 148d |  | start no earlier than 2022-03-03 | 257.15 |
| 23 | 1.5.1.4 | SOLEIRA DE MARMORE BRANCO CLASSICO,DE 3X25CM,COM 2 POLIMENTOS,ASSENTE COMO EM 13.345.0015 | 2d | 2022-03-03 | 2022-03-04 |  | 148d |  | start no earlier than 2022-03-03 | 1,491.21 |
| 24 | 1.5.2 | **LAJE** | 16d | 2021-08-12 | 2021-09-02 |  | 219d |  |  | 146,335.25 |
| 25 | 1.5.2.1 | CONCRETO DOSADO RACIONALMENTE PARA UMA RESISTENCIA CARACTERISTICA A COMPRESSAO DE 30MPA,COMPREENDENDO APENAS O FORNECIMENTO DOS MATERIAIS,INCLUSIVE 5% DE PERDAS | 10d | 2021-08-20 | 2021-09-02 | 27 | 219d | 29d | start no earlier than 2021-08-19 | 32,573.6 |
| 26 | 1.5.2.2 | BARRA DE ACO CA-50,COM SALIENCIA OU MOSSA,COEFICIENTE DE CONFORMACAO SUPERFICIAL MINIMO (ADERENCIA) IGUAL A 1,5,DIAMETRODE 8 A 12,5MM,DESTINADA A ARMADURA DE CONCRETO ARMADO,10%DE PERDAS DE PONTAS E ARAME 18.FORNECIMENTO | 5d | 2021-08-12 | 2021-08-18 | 8 | 290d |  |  | 44,600.64 |
| 27 | 1.5.2.3 | FORMAS DE CHAPAS DE MADEIRA COMPENSADA,DE 14MM DE ESPESSURA,RESINADAS,PARA LAJES,SERVINDO 2 VEZES,E MADEIRA AUXILIAR SERVINDO 2 VEZES,INCLUSIVE FORNECIMENTO E DESMOLDAGEM,EXCLUSIVEESCORAMEN TO | 6d | 2021-08-12 | 2021-08-19 | 8 | 219d | 0d | start no earlier than 2021-08-09 | 45,472.59 |
| 28 | 1.5.2.4 | ESCORAMENTO DE FORMA DE PARAMENTOS VERTICAIS,PARA ALTURA ATE 1,50M,COM 30% DE APROVEITAMENTO DA MADEIRA,INCLUSIVE RETIRADA | 2d | 2021-08-31 | 2021-09-01 | 8 | 280d |  | start no earlier than 2021-08-31 | 23,688.42 |

| ID | WBS | Task | Duration | Start | Finish | Predecessors | Total slack | Free slack | Constraint | Cost |
| --- | --- | --- | --- | --- | --- | --- | --- | --- | --- | --- |
| 29 | 1.5.3 | **PINTURA** | 132d | 2022-03-03 | 2022-09-02 |  | 18d |  |  | 101,009.62 |
| 30 | 1.5.3.1 | PREPARO DE SUPERFICIES NOVAS,COM REVESTIMENTO LISO,INCLUSIVE LIXAMENTO,LIMPEZA,UMA DEMAO DE SELADOR ACRILICO,UMA DEMAO DE MASSA CORRIDA OU ACRILICA E NOVO LIXAMENTO COM REMOCAO DOPO RESIDUAL | 35d | 2022-03-03 | 2022-04-20 | 20 | 115d |  | finish no earlier than 2022-03-30 | 45,723.34 |
| 31 | 1.5.3.2 | PINTURA COM TINTA LATEX,CLASSIFICACAO PREMIUM OU STANDARD (NBR 15079),FOSCA EM REVESTIMENTO LISO,INTERIOR,ACABAMENTO EMALTA CLASSE,EM TRES DEMAOS E MAIS UMA DEMAO DE MASSA CORRIDAE LIXAMENTO,SOBRE SUPERFICIE JA PREPARADA,CONFORME O ITEM 17.018.0010,EXCLUS | 20d | 2022-08-08 | 2022-09-02 | 39 | 18d |  | finish no earlier than 2022-04-27 | 55,286.28 |
| 32 | 1.5.4 | **REVESTIMENTO** | 40d | 2022-01-20 | 2022-03-16 |  | 140d |  |  | 66,998.2 |
| 33 | 1.5.4.1 | AJULEJO 30X60 RETIFICADO | 12d | 2022-01-20 | 2022-02-04 | 13 | 168d |  | finish no earlier than 2022-02-04 | 51,916.04 |
| 34 | 1.5.4.2 | RODAPE DE PVC TIPO HOSPITALAR,PLANO OU CURVO,COM 7,5CM DE ALTURA,PARA PISOS VINILICOS.FORNECIMENTO E COLOCACAO | 10d | 2022-03-03 | 2022-03-16 | 20 | 140d |  | start no earlier than 2022-01-20 | 15,082.16 |
| 35 | 1.5.5 | **FORRO DE GESSO** | 15d | 2022-01-20 | 2022-02-09 |  | 165d |  |  | 29,759.01 |
| 36 | 1.5.5.1 | FORRO DE GESSO ESTAFE,COM PLACAS DE 1,00X0,70M FUNDIDAS NA OBRA, PRESAS COM 6 ESBIRROS DE CANHAMO, EMBEBIDAS EM NATA DEGESSO E REJUNTADAS.FORNECIMENTO E COLOCACAO | 15d | 2022-01-20 | 2022-02-09 | 13 | 165d |  | finish no earlier than 2022-02-09 | 29,759.01 |
| 37 | 1.6 | **ACABAMENTOS EXTERNOS** | 55d | 2022-06-20 | 2022-09-02 |  | 18d |  |  | 108,998.21 |
| 38 | 1.6.1 | **PINTURA** | 50d | 2022-06-27 | 2022-09-02 |  | 18d |  |  | 89,677.26 |
| 39 | 1.6.1.1 | PREPARO DE SUPERFICIES NOVAS,COM REVESTIMENTO LISO,INCLUSIVE LIXAMENTO,LIMPEZA,UMA DEMAO DE SELADOR ACRILICO,UMA DEMAO DE MASSA CORRIDA OU ACRILICA E NOVO LIXAMENTO COM REMOCAO DOPO RESIDUAL | 30d | 2022-06-27 | 2022-08-05 | 14 | 18d | 0d | finish no earlier than 2022-08-05 | 24,560.31 |
| 40 | 1.6.1.2 | PINTURA INTERNA OU EXTERNA SOBRE CONCRETO LISO OU REVESTIMENTO,COM TINTA AQUOSA A BASE DE EPOXI INCOLOR OU EM CORES,INCLUSIVE LIMPEZA,E DUAS DEMAOS DE ACABAMENTO | 20d | 2022-08-08 | 2022-09-02 | 39 | 18d |  | finish no earlier than 2022-09-02 | 65,116.95 |
| 41 | 1.6.2 | **REVESTIMENTO** | 5d | 2022-06-20 | 2022-06-24 |  | 68d |  |  | 19,320.95 |
| 42 | 1.6.2.1 | Revestimento de paredes com cerâmica Gail, coleção natural ou similar, de (24x11,60x0,09)cm, assentes com argamassa de cimento, cal e areia no traço 1:3:5, juntas reentrantes de 1cm de largura.(desonerado) | 5d | 2022-06-20 | 2022-06-24 |  | 68d |  | finish no earlier than 2022-06-24 | 16,017.44 |
| 43 | 1.6.2.2 | PAREDE DE BLOCOS VAZADOS(COBOGO),DE CIMENTO E AREIA,COM PESO DE 9,6KG,39X39X7CM,ASSENTES COMO EM 12.006.0010 | 3d | 2022-06-20 | 2022-06-22 |  | 70d |  | finish no earlier than 2022-06-22 | 3,303.51 |
| 44 | 1.7 | **PISO EXTERNO** | 28d | 2022-06-09 | 2022-07-18 |  | 52d |  |  | 170,347.3 |
| 45 | 1.7.1 | **PISOS** | 21d | 2022-06-20 | 2022-07-18 |  | 52d |  |  | 60,905.18 |
| 46 | 1.7.1.1 | PORCELANATO TÉCNICO RETIFICADO 90X90 - NATURAL | 10d | 2022-07-05 | 2022-07-18 |  | 52d |  | finish no earlier than 2022-07-18 | 12,704.74 |
| 47 | 1.7.1.2 | CONTRAPISO,BASE OU CAMADA REGULARIZADORA,EXECUTADA COM ARGAMASSA DE CIMENTO E AREIA,NO TRACO 1:4,NA ESPESSURA DE 3,5CM | 8d | 2022-06-20 | 2022-06-29 |  | 65d |  | finish no earlier than 2022-06-29 | 15,915.51 |
| 48 | 1.7.1.3 | REVESTIMENTO DE PISO CERAMICO EM PORCELANATO TECNICO NATURAL,ACABAMENTO DA BORDA RETIFICADO,PARA USO EM AREAS COMERCIAISCOM ACESSO PARA RUA,NO FORMATO (60X60)CM,ASSENTES EM SUPERFICIE EM OSSO COM ARGAMASSA DE CIMENTO E COLA (ARGAMASSA COLANTE)E REJUNTAMEN | 4d | 2022-06-20 | 2022-06-23 |  | 69d |  | finish no earlier than 2022-06-23 | 10,034.25 |
| 49 | 1.7.1.4 | PISO CIMENTADO,COM 1,5CM DE ESPESSURA,COM ARGAMASSA DE CIMENTO E AREIA,NO TRACO 1:3,ALISADO A COLHER,COM CORANTE, SOBREBASE EXISTENTE | 2d | 2022-06-20 | 2022-06-21 |  | 71d |  | finish no earlier than 2022-06-21 | 4,375.83 |
| 50 | 1.7.1.5 | PISO ELEVADO EM PLACAS DE GRANITO CINZA ANDORINHA,MEDINDO APROXIMADAMENTE (50X50X2)CM,PARA CIRCULACAO DE PEDESTRES E DEPEQUENAS CARGAS ROLANTES (CADEIRA DE RODAS E BICICLETA),PARAAREAS INTERNAS OU EXTERNAS,APOIADO EM PEDESTAIS REGULAVEISDE POLIPROPILENO O | 9d | 2022-06-20 | 2022-06-30 |  | 64d |  | finish no earlier than 2022-06-30 | 17,874.85 |
| 51 | 1.7.2 | **LAJE** | 7d | 2022-06-09 | 2022-06-17 |  | 73d |  |  | 109,442.12 |
| 52 | 1.7.2.1 | CONCRETO DOSADO RACIONALMENTE PARA UMA RESISTENCIA CARACTERISTICA A COMPRESSAO DE 30MPA,COMPREENDENDO APENAS O FORNECIMENTO DOS MATERIAIS,INCLUSIVE 5% DE PERDAS | 2d | 2022-06-16 | 2022-06-17 |  | 73d |  | finish no earlier than 2022-06-17 | 24,361.35 |
| 53 | 1.7.2.2 | BARRA DE ACO CA-50,COM SALIENCIA OU MOSSA,COEFICIENTE DE CONFORMACAO SUPERFICIAL MINIMO (ADERENCIA) IGUAL A 1,5,DIAMETRODE 8 A 12,5MM,DESTINADA A ARMADURA DE CONCRETO ARMADO,10%DE PERDAS DE PONTAS E ARAME 18.FORNECIMENTO | 5d | 2022-06-09 | 2022-06-15 |  | 75d |  | finish no earlier than 2022-06-15 | 33,356.2 |
| 54 | 1.7.2.3 | FORMAS DE CHAPAS DE MADEIRA COMPENSADA,DE 14MM DE ESPESSURA,RESINADAS,PARA LAJES,SERVINDO 2 VEZES,E MADEIRA AUXILIAR SERVINDO 2 VEZES,INCLUSIVE FORNECIMENTO E DESMOLDAGEM,EXCLUSIVEESCORAMEN TO | 5d | 2022-06-09 | 2022-06-15 |  | 75d |  | finish no earlier than 2022-06-15 | 34,008.33 |
| 55 | 1.7.2.4 | ESCORAMENTO DE FORMA DE PARAMENTOS VERTICAIS,PARA ALTURA ATE 1,50M,COM 30% DE APROVEITAMENTO DA MADEIRA,INCLUSIVE RETIRADA | 1d | 2022-06-16 | 2022-06-16 |  | 74d |  | start no earlier than 2022-06-16 | 17,716.24 |

| ID | WBS | Task | Duration | Start | Finish | Total slack | Constraint | Cost |
| --- | --- | --- | --- | --- | --- | --- | --- | --- |
| 56 | 1.8 | **ESQUADRIAS** | 25d | 2021-09-30 | 2021-11-03 | 235d |  | 157,125.98 |
| 57 | 1.8.1 | **PORTAS** | 20d | 2021-09-30 | 2021-10-27 | 240d |  | 79,068.04 |
| 58 | 1.8.1.1 | PORTA DE MADEIRA DE LEI EM COMPENSADO DE 70X210X3,5CM,FOLHEADA NAS 2 FACES,ADUELA DE 13X3CM E ALIZARES DE 5X2CM,EXCLUSIVE FERRAGENS.FORNECIMENTO E COLOCACAO | 0.5d | 2021-09-30 | 2021-09-30 | 259.5d | start no earlier than 2021-09-30 | 496.26 |
| 59 | 1.8.1.2 | PORTA DE MADEIRA DE LEI EM COMPENSADO DE 80X210X3,5CM FOLHEADA NAS 2 FACES,ADUELA DE 13X3CM E ALIZARES DE 5X2CM,EXCLUSIVE FERRAGENS.FORNECIMENTO E COLOCACAO | 5d | 2021-09-30 | 2021-10-06 | 255d | finish no earlier than 2021-10-06 | 13,529.4 |
| 60 | 1.8.1.3 | PORTA DE MADEIRA DE LEI EM COMPENSADO DE 90X210X3,5CM FOLHEADA NAS 2 FACES,ADUELA DE 13X3CM E ALIZARES DE 5X2CM,EXCLUSIVE FERRAGENS.FORNECIMENTO E COLOCACAO | 3d | 2021-09-30 | 2021-10-04 | 257d | finish no earlier than 2021-10-04 | 4,871.89 |
| 61 | 1.8.1.4 | PORTA DE MADEIRA DE LEI EM COMPENSADO DE 100X210X3,5CM,FOLHEADA NAS 2 FACES,ADUELA DE 13X3CM E ALIZARES DE 5X2CM,EXCLUSIVE FERRAGENS.FORNECIMENTO E COLOCACAO | 1d | 2021-09-30 | 2021-09-30 | 259d | start no earlier than 2021-09-30 | 1,653.61 |
| 62 | 1.8.1.5 | PORTA DE MADEIRA DE LEI EM COMPENSADO DE 100X210X3,5CM,FOLHEADA NAS 2 FACES,ADUELA DE 13X3CM E ALIZARES DE 5X2CM,EXCLUSIVE FERRAGENS.FORNECIMENTO E COLOCACAO | 1.5d | 2021-09-30 | 2021-10-01 | 258d | finish no earlier than 2021-10-01 | 3,307.22 |
| 63 | 1.8.1.6 | PORTA DE MADEIRA DE LEI EM COMPENSADO DE 120X210X3,5CM,EM 2 FOLHAS,ADUELA DE 13X3CM E ALIZARES 5X2CM,EXCLUSIVE FERRAGENS.FORNECIMENTO E COLOCACAO | 1d | 2021-09-30 | 2021-09-30 | 259d | start no earlier than 2021-09-30 | 3,272.02 |
| 64 | 1.8.1.7 | PORTA DE MADEIRA DE LEI EM COMPENSADO DE 160CMX210X3,5CM,EM 2 FOLHAS,ADUELA DE 13X3CM E ALIZARES DE 5X2CM,EXCLUSIVE FERRAGENS.FORNECIMENTO E COLOCACAO | 1d | 2021-09-30 | 2021-09-30 | 259d | start no earlier than 2021-09-30 | 833.83 |
| 65 | 1.8.1.8 | PORTA DE ALUMINIO ANODIZADO EM BRONZE OU PRETO,DE CORRER,COM 2 FOLHAS,TENDO 1 CONTRAPINAZIO DIVIDINDO A ESQUADRIA EM 2 VAZIOS PARA VIDRO,EM PERFIS SERIE 25,EXCLUSIVE FECHADURA.FORNECIMENTO E COLOCACAO | 1d | 2021-09-30 | 2021-09-30 | 259d | start no earlier than 2021-09-30 | 6,582.58 |
| 66 | 1.8.1.9 | SENSOR AUMOMATICO PARA PORTA DE VIDRO DE CORRER | 2d | 2021-09-30 | 2021-10-01 | 258d | finish no earlier than 2021-10-01 | 543.02 |
| 67 | 1.8.1.10 | PORTA DE ALUMINIO ANODIZADO AO NATURAL,PERFIL SERIE 25,EM LAMBRI HORIZONTAL,EXCLUSIVE FECHADURA.FORNECIMENTO E COLOCACAO | 1d | 2021-09-30 | 2021-09-30 | 259d | start no earlier than 2021-09-30 | 4,665.85 |
| 68 | 1.8.1.11 | PORTA DE ALUMINIO ANODIZADO AO NATURAL,PERFIL SERIE 25,EM VENEZIANA,EXCLUSIVE FECHADURA.FORNECIMENTO E COLOCACAO | 1d | 2021-09-30 | 2021-09-30 | 259d | start no earlier than 2021-09-30 | 16,797.05 |
| 69 | 1.8.1.12 | PORTA DE ALUMINIO ANODIZADO AO NATURAL,PERFIL SERIE 25,EM VENEZIANA,EXCLUSIVE FECHADURA.FORNECIMENTO E COLOCACAO | 1d | 2021-09-30 | 2021-09-30 | 259d | start no earlier than 2021-09-30 | 11,198.03 |
| 70 | 1.8.1.13 | FERRAGENS P/PORTA DE MADEIRA,DE 1 FOLHA DE ABRIR,DE ENTRADA PRINCIPAL, CONSTANDO DE FORNEC.S/COLOCACAO,DE:-FECHADU RA DECILINDRO DE FERRO,ACABAMENTO CROMADO -MACANETA TIPO BOLA EMZAMAK POLIDO E CROMADO -ESPELHO RETANGULAR EM FERRO POLIDO,ACABAMENTO CROMAD | 20d | 2021-09-30 | 2021-10-27 | 240d | finish no earlier than 2021-10-27 | 9,834.72 |
| 71 | 1.8.1.14 | FERRAGENS PARA PAINEIS FIXOS DE VIDRO TEMPERADO DE 10MM(CONJUNTO COMPLETO),CONSTANDO DE FORNECIMENTO SEM COLOCACAO(ESTAINCLUIDA NO FORNECIMENTO E COLOCACAO DO VIDRO) | 4d | 2021-09-30 | 2021-10-05 | 256d | finish no earlier than 2021-10-05 | 470.56 |
| 72 | 1.8.1.15 | FERRAGENS PARA PORTAS DE ABRIR,DE FERRO OU ALUMINIO,CONSTANDO DE FORNECIMENTO DAS PECAS:-FECHADURA DE CILINDRO OVALADO PARA MONTANTES ESTREITOS,EM LATAO,ACABAMENTO CROMADO -ESPELHORETANGULAR,EM LATAO,ACABAMENTO CROMADO OU ROSETA CIRCULAR EM LATAO,ACABAMEN | 2d | 2021-10-14 | 2021-10-15 | 248d | finish no earlier than 2021-10-15 | 1,012 |
| 73 | 1.8.2 | **JANELAS** | 20d | 2021-10-07 | 2021-11-03 | 235d |  | 78,057.94 |
| 74 | 1.8.2.1 | CAIXILHO FIXO DE ALUMINIO ANODIZADO AO NATURAL,SERIE 28,PARA VIDRO.FORNECIMENTO E COLOCACAO | 20d | 2021-10-07 | 2021-11-03 | 235d | finish no earlier than 2021-11-03 | 27,285.68 |
| 75 | 1.8.2.2 | VIDRO TEMPERADO INCOLOR,10MM DE ESPESSURA,PARA PORTAS OU PAINEIS FIXOS,EXCLUSIVE FERRAGENS.FORNECIMENTO E COLOCACAO | 20d | 2021-10-07 | 2021-11-03 | 235d | finish no earlier than 2021-11-03 | 28,094.21 |
| 76 | 1.8.2.3 | FERRAGENS PARA PAINEIS FIXOS DE VIDRO TEMPERADO DE 10MM(CONJUNTO COMPLETO),CONSTANDO DE FORNECIMENTO SEM COLOCACAO(ESTAINCLUIDA NO FORNECIMENTO E COLOCACAO DO VIDRO) | 12d | 2021-10-07 | 2021-10-22 | 243d | finish no earlier than 2021-10-22 | 3,764.48 |
| 77 | 1.8.2.4 | CORRIMAO DE TUBO DE FERRO GALVANIZADO DE 1.1/4",PRESO POR CHUMBADORES A CADA METRO.FORNECIMENTO E COLOCACAO | 3d | 2021-10-07 | 2021-10-11 | 252d | finish no earlier than 2021-10-11 | 177.31 |
| 78 | 1.8.2.5 | VENEZIANA VERTICAL(BRISE SOLEIL)DE CHAPA DE ALUMINIO,COM 1,2MM DE ESPESSURA,FIXADO EM CANTONEIRAS DE ACO APARAFUSADAS,EMEDIDA PELA AREA COLOCADA.FORNECIMENTO E COLOCACAO | 3d | 2021-10-07 | 2021-10-11 | 252d | finish no earlier than 2021-10-11 | 18,736.26 |
| 79 | 1.9 | **HIDROSSANITÁRIAS** | 53d | 2021-08-02 | 2021-10-13 | 250d |  | 260,323.94 |
| 80 | 1.9.1 | LAVATORIO DE LOUCA BRANCA TIPO MEDIO LUXO,COM LADRAO E MEDIDAS EM TORNO DE 55X45CM,COM COLUNA,INCLUSIVE ACESSORIOS DE FIXACAO.FERRAGENS EM METAL CROMADO:SIFAO 1680 DE 1"X1.1/4",APARELHO MISTURADOR TIPO BANCA,1875 OU SIMILAR,COM AREJADOR,VALVULA DE ESCOAME | 10d | 2021-09-02 | 2021-09-15 | 270d | finish no earlier than 2021-09-15 | 11,517.84 |
| 81 | 1.9.2 | ASSENTAMENTO DE LAVATORIO(EXCLUSIVE FORNECIMENTO DO APARELHO),INCLUSIVE MATERIAIS NECESSARIOS | 3d | 2021-09-02 | 2021-09-06 | 277d | start no earlier than 2021-09-02 | 1,775.17 |
| 82 | 1.9.3 | TORNEIRA DE FECHAMENTO AUTOMATICO,PARA LAVATORIO,DE PAREDE,ANTIVANDALISMO,DE 135MM,ACABAMENTO CROMADO.FORNECIMENTO | 4d | 2021-09-02 | 2021-09-07 | 276d | finish no earlier than 2021-09-07 | 9,638.4 |
| 83 | 1.9.4 | CUBA DE ACO INOXIDAVEL,MEDINDO APROXIMADAMENTE (500X400X200)MM,EM CHAPA 20.304,VALVULA DE ESCOAMENTO TIPO AMERICANA 1623,SIFAO 1680 1.1/2" X 1.1/2",EXCLUSIVE TORNEIRA.FORNECIMENTOE COLOCACAO | 5d | 2021-09-02 | 2021-09-08 | 275d | finish no earlier than 2021-09-08 | 4,190.14 |
| 84 | 1.9.5 | TORNEIRA DE FECHAMENTO AUTOMATICO,PARA LAVATORIO,DE PAREDE,ANTIVANDALISMO,DE 135MM,ACABAMENTO CROMADO.FORNECIMENTO | 10d | 2021-09-02 | 2021-09-15 | 270d | finish no earlier than 2021-09-15 | 9,638.4 |
| 85 | 1.9.6 | TANQUE | 1d | 2021-09-02 | 2021-09-02 | 279d | start no earlier than 2021-09-02 | 732.82 |
| 86 | 1.9.7 | TORNEIRA DE FECHAMENTO AUTOMATICO,PARA LAVATORIO,DE PAREDE,ANTIVANDALISMO,DE 135MM,ACABAMENTO CROMADO.FORNECIMENTO | 4d | 2021-09-02 | 2021-09-07 | 276d | finish no earlier than 2021-09-07 | 401.6 |
| 87 | 1.9.8 | VASO SANITARIO DE LOUCA BRANCA,TIPO MEDIO LUXO,COM CAIXA ACOPLADA,INCLUSIVE RABICHO CROMADO DE 40CM,COM SAIDA DE 1/2",BOLSA DE LIGACAO E ACESSORIOS DE FIXACAO.FORNECIMENTO | 5d | 2021-09-02 | 2021-09-08 | 275d | finish no earlier than 2021-09-08 | 5,198.64 |
| 88 | 1.9.9 | INSTALACAO E ASSENTAMENTO DE UM VASO SANITARIO E CAIXA ACOPLADA(EXCL.ESTES)EM PAVIMENTO TERREO,PARTE DE UM CONJ.DE DOISOU MAIS VASOS,COMPREENDENDO:INST.HIDRA ULICA COM 1,50M DE TUBO PVC 25MM,COM CONEXOES,ATE A CAIXA ACOPLADA,LIGACAO DE ESGOTO COM 2,00M DE | 3d | 2021-09-02 | 2021-09-06 | 277d | finish no earlier than 2021-09-06 | 3,092.68 |
| 89 | 1.9.10 | VASO SANITARIO DE LOUCA BRANCA,CONVENCIONAL,TIPO MEDIO LUXO,COM MEDIDAS EM TORNO DE 37X47X38CM,INCL.ASSENTO PLASTICO TIPO MEDIO LUXO,BOLSA DE LIGACAO,VALVULA DE DESCARGA DE 1.1/2"C/REGISTRO INTEGRADO,SISTEMA HIDROMECANICO(ISENTA DE GOLPE DE ARIETE)COM COR | 1d | 2021-09-02 | 2021-09-02 | 279d | start no earlier than 2021-09-02 | 623.22 |
| 90 | 1.9.11 | INSTALACAO E ASSENTAMENTO DE UM VASO SANITARIO E CAIXA ACOPLADA(EXCL.ESTES)EM PAVIMENTO TERREO,PARTE DE UM CONJ.DE DOISOU MAIS VASOS,COMPREENDENDO:INST.HIDRA ULICA COM 1,50M DE TUBO PVC 25MM,COM CONEXOES,ATE A CAIXA ACOPLADA,LIGACAO DE ESGOTO COM 2,00M DE | 3d | 2021-09-02 | 2021-09-06 | 277d | finish no earlier than 2021-09-06 | 3,092.68 |
| 91 | 1.9.12 | BARRA DE APOIO EM ACO INOXIDAVEL AISI 304,TUBO DE 1.1/4",EM "L",INCLUSIVE FIXACAO COM PARAFUSOS INOXIDAVEIS E BUCHAS PLASTICAS,MEDINDO 70X70CM,PARA PESSOAS COM NECESSIDADES ESPECIFICAS.FORNECIMENTO E COLOCACAO | 2d | 2021-09-02 | 2021-09-03 | 278d | finish no earlier than 2021-09-03 | 987.98 |
| 92 | 1.9.13 | CHUVEIRO DE LUXO,ARTICULADO,COM BRACO DE 1/2" E 2 REGISTROS DE PRESSAO 1416,DE 1/2",COM CANOPLA E VOLANTE EM METAL CROMADO.FORNECIMENTO | 6d | 2021-09-02 | 2021-09-09 | 274d | finish no earlier than 2021-09-09 | 504.18 |
| 93 | 1.9.14 | TUBO PVC (NBR-7362), PARA ESGOTO SANITARIO, COM DIAMETRO NOMINAL DE 100MM, INCLUSIVE ANEL DE BORRACHA. FORNECIMENTO | 25d | 2021-09-02 | 2021-10-06 | 255d | finish no earlier than 2021-10-06 | 16,233.7 |
| 94 | 1.9.15 | Joelho de PVC rígido, 90°, série R, ponta e bolsa, diâmetro de 100mm. Fornecimento e instalação. | 25d | 2021-09-02 | 2021-10-06 | 255d | finish no earlier than 2021-10-06 | 5,765.3 |
| 95 | 1.9.16 | Curva curta de 45° de PVC rígido, Vinilfort, com 1 ponta e 1 bolsa, inclusive fornecimento do material para junta (anel de borracha e lubrificante) diâmetro de 100mm. Fornecimento e assentamento. | 25d | 2021-09-02 | 2021-10-06 | 255d | finish no earlier than 2021-10-06 | 5,408.94 |
| 96 | 1.9.17 | Junção de 45° de PVC rígido, Vinilfort com 3 bolsas, inclusive fornecimento do material para junta (anel de borracha e lubrificante) diâmetro de 100mm. Fornecimento e assentamento. | 30d | 2021-09-02 | 2021-10-13 | 250d | finish no earlier than 2021-10-13 | 7,516.75 |
| 97 | 1.9.18 | TUBO PARA VENTILACAO EM PVC DE 100MM.INCLUSIVE CONEXOES.FORNECIMENTO E ASSENTAMENTO | 30d | 2021-09-02 | 2021-10-13 | 250d | finish no earlier than 2021-10-13 | 4,472.56 |
| 98 | 1.9.19 | TUBO DE PVC RIGIDO SOLDAVEL,PARA AGUA FRIA, COM DIAMETRO DE 40MM.FORNECIMENTO | 30d | 2021-09-02 | 2021-10-13 | 250d | finish no earlier than 2021-10-13 | 4,246.68 |
| 99 | 1.9.20 | TUBO DE PVC RIGIDO SOLDAVEL,PARA AGUA FRIA, COM DIAMETRO DE 60MM.FORNECIMENTO | 30d | 2021-09-02 | 2021-10-13 | 250d | finish no earlier than 2021-10-13 | 7,150.52 |
| 100 | 1.9.21 | RALO SIFONADO DE PVC(100X100)X50MM,EM PAVIMENTO TERREO,COM TAMPA CEGA,COM 1 ENTRADA DE 40MM E SAIDA DE 50MM,INCLUSIVE LIGACAO DE 50MM DE PVC ATE A CAIXA DE INSPECAO,CONSIDERANDO ADISTANCIA DO CENTRO DO RALO ATE 2,00M.FORNECIMENTO E INSTALACAO | 30d | 2021-09-02 | 2021-10-13 | 250d | finish no earlier than 2021-10-13 | 3,063.83 |
| 101 | 1.9.22 | RALO SECO(SIMPLES)DE PVC(100X53)X40MM,COM GRELHA,COMPREENDENDO:EFLUENTE DE 40MM SOLDAVEL EM PVC,COM 2,00M DE EXTENSAO ELIGACAO AO RALO SIFONADO.FORNECIMENTO E INSTALACAO | 30d | 2021-09-02 | 2021-10-13 | 250d | finish no earlier than 2021-10-13 | 159.23 |
| 102 | 1.9.23 | RALO DE COBERTURA SEMI-ESFERICO(TIPO ABACAXI),COM 3".FORNECIMENTO E COLOCACAO | 30d | 2021-09-02 | 2021-10-13 | 250d | finish no earlier than 2021-10-13 | 246.48 |
| 103 | 1.9.24 | POCO DE VISITA DE CONCRETO ARMADO COM MEDIDAS INTERNAS DO POCO E PROFUNDIDADE DE 1,10X1,10X1,20M,DIAMETRO DA GALERIA DE0,60M,TENDO O CONCRETO DAS PAREDES,FUNDO E TAMPA 400KG E O DA BASE,CALHA E BANQUETA 300KG DE CIMENTO POR M3,SENDO AS PAREDES,CALHA E A B | 30d | 2021-09-02 | 2021-10-13 | 250d | finish no earlier than 2021-10-13 | 21,969.65 |
| 104 | 1.9.25 | CAIXA DE RALO EM ALVENARIA DE BLOCOS DE CONCRETO(20X20X40CM),EM PAREDES DE 0,20M DE ESPESSURA,DE 0,30X0,90X0,90M,PARA AGUAS PLUVIAIS,SENDO AS PAREDES CHAPISCADAS E REVESTIDAS INTERNAMENTE COM ARGAMASSA,ENCHIMENTO DOS BLOCOS E BASE EM CONCRETO SIMPLES FCK= | 30d | 2021-09-02 | 2021-10-13 | 250d | finish no earlier than 2021-10-13 | 6,959.34 |
| 105 | 1.9.26 | TUBO DE POLIETILENO DE ALTA DENSIDADE(PEAD),RESINA PE80/100,NORMA ISO 4427, CLASSE PN-10, DE=400MM. FORNECIMENTO | 30d | 2021-09-02 | 2021-10-13 | 250d | finish no earlier than 2021-10-13 | 84,096 |
| 106 | 1.9.27 | REGISTRO DE GAVETA,EM BRONZE,COM DIAMETRO DE 1.1/4".FORNECIMENTO E COLOCACAO | 30d | 2021-09-02 | 2021-10-13 | 250d | finish no earlier than 2021-10-13 | 2,792.78 |
| 107 | 1.9.28 | REGISTRO DE PRESSAO,1416 DE 1/2",COM CANOPLA E VOLANTE EM METAL CROMADO.FORNECIMENTO | 30d | 2021-09-02 | 2021-10-13 | 250d | finish no earlier than 2021-10-13 | 113.7 |
| 108 | 1.9.29 | BOMBA | 5d | 2021-09-02 | 2021-09-08 | 275d | finish no earlier than 2021-09-08 | 17,326.05 |
| 109 | 1.9.30 | CAIXA DE INSPECAO/CAIXA PARA AGUAS PLUVIAIS,DE CONCRETO PRE-MOLDADO,CONSTANDO DE CIRCULO DE FUNDO,3 ANEIS SUPERPOSTOS,DE40MM DE ESPESSURA E 600MM DE DIAMETRO INTERNO,SENDO 1 ANELINFERIOR(ENTRADA E SAIDA)DE 300MM,1 DE 150MM E 1 DE 75MM DEALTURA,PERFAZENDO | 1d | 2021-09-02 | 2021-09-02 | 279d | start no earlier than 2021-09-02 | 3,098.18 |
| 110 | 1.9.31 | CAIXA DE GORDURA ESPECIAL DE ALVENARIA DE TIJOLOS MACICOS(7X10X20CM),EM PAREDES DE UMA VEZ(0,20M),MEDINDO 1,00X1,00X0,90M,INCLUSIVE REVESTIMENTO INTERNO EM ARGAMASSA DE CIMENTO E AREIA,NO TRACO 1:3,COM ESPESSURA DE 1,5CM,EXCLUSIVE TAMPAO DEFERRO FUNDIDO | 30d | 2021-09-02 | 2021-10-13 | 250d | finish no earlier than 2021-10-13 | 8,429.11 |
| 111 | 1.9.32 | CAIXA D'AGUA VERTICAL 9 M DE ALTURA E DIAMETRO DE 1,76 | 1d | 2021-08-02 | 2021-08-02 | 302d |  |  |
| 112 | 1.9.33 | CONCRETO DOSADO RACIONALMENTE PARA UMA RESISTENCIA CARACTERISTICA A COMPRESSAO DE 30MPA,COMPREENDENDO APENAS O FORNECIMENTO DOS MATERIAIS,INCLUSIVE 5% DE PERDAS | 2d | 2021-09-02 | 2021-09-03 | 278d | finish no earlier than 2021-09-03 | 2,880.17 |
| 113 | 1.9.34 | BARRA DE ACO CA-50,COM SALIENCIA OU MOSSA,COEFICIENTE DE CONFORMACAO SUPERFICIAL MINIMO (ADERENCIA) IGUAL A 1,5,DIAMETRODE 8 A 12,5MM,DESTINADA A ARMADURA DE CONCRETO ARMADO,10%DE PERDAS DE PONTAS E ARAME 18.FORNECIMENTO | 4d | 2021-09-02 | 2021-09-07 | 276d | finish no earlier than 2021-09-07 | 3,943.6 |
| 114 | 1.9.35 | FORMAS DE CHAPAS DE MADEIRA COMPENSADA,DE 14MM DE ESPESSURA,RESINADAS,PARA LAJES,SERVINDO 2 VEZES,E MADEIRA AUXILIAR SERVINDO 2 VEZES,INCLUSIVE FORNECIMENTO E DESMOLDAGEM,EXCLUSIVEESCORAMEN TO | 4d | 2021-09-02 | 2021-09-07 | 276d | finish no earlier than 2021-09-07 | 2,010.35 |
| 115 | 1.9.36 | ESCORAMENTO DE FORMA DE PARAMENTOS VERTICAIS,PARA ALTURA ATE 1,50M,COM 30% DE APROVEITAMENTO DA MADEIRA,INCLUSIVE RETIRADA | 1d | 2021-09-02 | 2021-09-02 | 279d | start no earlier than 2021-09-02 | 1,047.27 |
| 116 | 1.9.37 | LIGAÇÃO COM A REDE EXTERNA DE ÁGUA | 1d | 2021-08-02 | 2021-08-02 | 302d |  |  |
| 117 | 1.9.38 | LIGAÇÃO COM A REDE EXTERNA DE ESGOTO | 1d | 2021-08-02 | 2021-08-02 | 302d |  |  |
| 118 | 1.9.39 | HIDROMETRO | 1d | 2021-08-02 | 2021-08-02 | 302d |  |  |
| 119 | 1.9.40 | ABRIGO PRA HIDROMETRO | 1d | 2021-08-02 | 2021-08-02 | 302d |  |  |

| ID | WBS | Task | Duration | Start | Finish | Total slack | Constraint | Cost |
| --- | --- | --- | --- | --- | --- | --- | --- | --- |
| 120 | 1.10 | **ELÉTRICA DADOS E VOZ** | 60d | 2021-09-30 | 2021-12-22 | 200d |  | 124,385.43 |
| 121 | 1.10.1 | LUMINARIA DE EMBUTIR,FIXADA EM GESSO,PARA LAMPADA LED DE 25W (INCLUSIVE LAMPADA).FORNECIMENTO E COLOCACAO | 60d | 2021-09-30 | 2021-12-22 | 200d | finish no earlier than 2021-12-22 | 19,595.71 |
| 122 | 1.10.2 | INSTALACAO DE PONTO DE LUZ,INSTALACAO APARENTE COM CANALETA PERFURADA,SENDO ESTA LIGADA A ELETROCALHA PRINCIPAL(EXCLUSIVE ESTA)EQUIVALENTE A 1 VARA DE CANALETA E 2 VARAS DE ELETRODUTO DE PVC RIGIDO DE 3/4",24,00M DE FIO 2,5MM2,CAIXAS,CONEXOES,LUVAS,C URVA | 60d | 2021-09-30 | 2021-12-22 | 200d | finish no earlier than 2021-12-22 | 14,900.29 |
| 123 | 1.10.3 | INSTALACAO DE UM CONJUNTO DE 2 PONTOS DE LUZ,APARENTE,EQUIVALENTE A 5 VARAS DE ELETRODUTO RIGIDO,DE ACO CARBONO ESMALTADO,DE 3/4",33,00M DE FIO 2,5MM2,CAIXAS,CONEXOES,LUVAS,C URVA EINTERRUPTOR DE SOBREPOR COM PLACA FOSFORESCENTE | 60d | 2021-09-30 | 2021-12-22 | 200d | finish no earlier than 2021-12-22 | 7,671.84 |
| 124 | 1.10.4 | INSTALACAO DE UM CONJUNTO DE 3 PONTOS DE LUZ,APARENTE,EQUIVALENTE A 6 VARAS DE ELETRODUTO RIGIDO,DE ACO CARBONO ESMALTADO,DE 3/4",50,00 DE FIO 2,5MM2,CAIXAS,CONEXOES,LUVAS,C URVA EINTERRUPTOR DE SOBREPOR COM PLACA FOSFORESCENTE | 45d | 2021-09-30 | 2021-12-01 | 215d | finish no earlier than 2021-12-01 | 703.59 |
| 125 | 1.10.5 | INSTALACAO DE UM CONJUNTO DE 4 PONTOS DE LUZ,EMBUTIDO NA LAJE,EQUIVALENTE A 7 VARAS DE ELETRODUTO DE PVC RIGIDO DE 3/4",50,00M DE FIO 2,5MM2,CAIXAS,CONEXOES,LUVAS,C URVA E INTERRUPTOR DE EMBUTIR COM PLACA FOSFORESCENTE,INCLUSIVE ABERTURA E FECHAMENTO DE R | 5d | 2021-09-30 | 2021-10-06 | 255d | finish no earlier than 2021-10-06 | 794.33 |
| 126 | 1.10.6 | INSTALACAO DE UM CONJUNTO DE 6 PONTOS DE LUZ,APARENTE COM CANALETA PERFURADA,SENDO ESTA LIGADA A ELETROCALHA PRINCIPAL(EXCLUSIVE ESTA),EQUIVALENTE A 5 VARAS DE CANALETA E 2 VARAS DE ELETRODUTO DE PVC RIGIDO DE 3/4",78,00M DE FIO 2,5MM2,CAIXAS,CONEXOES,LUV | 60d | 2021-09-30 | 2021-12-22 | 200d | finish no earlier than 2021-12-22 | 3,012.72 |
| 127 | 1.10.7 | INSTALACAO DE PONTO DE TOMADA,APARENTE COM CANALETA PERFURADA,SENDO ESTA LIGADA A ELETROCALHA PRINCIPAL(EXCLUSIVE ESTA)EQUIVALENTE A 1 VARA DE CANALETA E 4 VARAS DE ELETRODUTO DE PVC RIGIDO DE 3/4", 36,00M DE FIO 2,5MM2,CAIXAS,CONEXOES E TOMADA DE SOBREPO | 60d | 2021-09-30 | 2021-12-22 | 200d | finish no earlier than 2021-12-22 | 73,734.7 |
| 128 | 1.10.8 | INSTALACAO DE PONTO DE TELEFONE E LOGICA,COMPREENDENDO:2 VARAS DE ELETRODUTO DE 3/4",CONEXOES E CAIXAS,EXCLUSIVE CABOS OU FIOS | 60d | 2021-09-30 | 2021-12-22 | 200d | finish no earlier than 2021-12-22 | 3,972.25 |
| 129 | 1.10.9 | CABOS | 1d | 2021-09-30 | 2021-09-30 | 259d | start no earlier than 2021-09-30 |  |
| 130 | 1.10.10 | ELETRODUTOS FLEXÍVEL | 1d | 2021-09-30 | 2021-09-30 | 259d | start no earlier than 2021-09-30 |  |
| 131 | 1.10.11 | ELETRODUTOS RÍGIDO | 1d | 2021-09-30 | 2021-09-30 | 259d | start no earlier than 2021-09-30 |  |
| 132 | 1.10.12 | QUADROS | 1d | 2021-09-30 | 2021-09-30 | 259d | start no earlier than 2021-09-30 |  |
| 133 | 1.10.13 | DISJUNTORES | 1d | 2021-09-30 | 2021-09-30 | 259d | start no earlier than 2021-09-30 |  |
| 134 | 1.10.14 | BRAÇADEIRAS | 1d | 2021-09-30 | 2021-09-30 | 259d | start no earlier than 2021-09-30 |  |
| 135 | 1.10.15 | ABERTURA E RASGO DE ALVENARIA | 1d | 2021-09-30 | 2021-09-30 | 259d | start no earlier than 2021-09-30 |  |
| 136 | 1.10.16 | ARANDELA | 1d | 2021-09-30 | 2021-09-30 | 259d | start no earlier than 2021-09-30 |  |
| 137 | 1.10.17 | LIGAÇÃO COM REDE EXTERNA - ENERGIA | 1d | 2021-09-30 | 2021-09-30 | 259d | start no earlier than 2021-09-30 |  |
| 138 | 1.10.18 | LIGAÇÃO COM REDE EXTERNA - DADOS | 1d | 2021-09-30 | 2021-09-30 | 259d | start no earlier than 2021-09-30 |  |
| 139 | 1.11 | **COBERTURA** | 31d | 2021-08-26 | 2021-10-07 | 254d |  | 140,155.55 |
| 140 | 1.11.1 | Cobertura termo-isolante, dupla, tipo sanduíche, trapezoidal, de aço galvanizado 0,43mm, para uso onde se requer conforto térmico, dupla estanqueidade lateral (superior/inferior) e pintura nas 2 faces, recheio de poliéster expandido (EPS altura = 40mm) co | 20d | 2021-09-03 | 2021-09-30 | 259d | finish no earlier than 2021-09-30 | 75,940.27 |
| 141 | 1.11.2 | MADEIRAMENTO PARA COBERTURA EM TELHAS ONDULADAS,CONSTITUIDO DE PECAS DE 3"X3" E 3"X4.1/2",EM MADEIRA APARELHADA,SEM TESOURA OU PONTALETE,MEDIDO PELA AREA REAL DO MADEIRAMENTO.FORNECIMENTO E COLOCACAO | 10d | 2021-08-26 | 2021-09-08 | 275d | finish no earlier than 2021-09-08 | 14,990.39 |
| 142 | 1.11.3 | COBERTURA EM CHAPA DE POLICARBONATO ALVEOLAR,NA COR CRISTAL,COM 10MM DE ESPESSURA,INCL.MADEIRAMENTO EM PECAS DE MADEIRAE PILARES EM TUBO DE ACO GALVANIZADO.MEDIDO PELA AREA REAL DE COBERTURA.FORNECIMENTO E COLOCACAO | 5d | 2021-09-09 | 2021-09-15 | 270d | finish no earlier than 2021-09-15 | 14,709.92 |
| 143 | 1.11.4 | ESTRUTURA DE ALUMINIO PARA CLARABOIA EM CHAPA DE POLICARBONATO,EXCLUSIVE ESTA.FORNECIMENTO E COLOCACAO | 1d | 2021-09-16 | 2021-09-16 | 269d | start no earlier than 2021-09-16 | 18,723.03 |
| 144 | 1.11.5 | ESCADA DE MARINHEIRO,COM LARGURA DE 0,40M,EXECUTADA EM BARRAS DE FERRO DE 1.1/2"X1/4",SENDO OS DEGRAUS EM FERRO REDONDODE 5/8",ESPACADOS DE 30CM.FORNECIMENTO E COLOCACAO | 2d | 2021-09-17 | 2021-09-20 | 267d | finish no earlier than 2021-09-20 | 1,998.22 |
| 145 | 1.11.6 | TUBO PVC (NBR-7362), PARA ESGOTO SANITARIO, COM DIAMETRO NOMINAL DE 100MM, INCLUSIVE ANEL DE BORRACHA. FORNECIMENTO | 4d | 2021-09-21 | 2021-09-24 | 263d | finish no earlier than 2021-09-24 | 861.38 |
| 146 | 1.11.7 | ESTRUTURA METALICA PARA COBERTURA DE GALPAO EM ARCO OU EM DUAS OU MAIS AGUAS,COM TRELICAS,TERCAS,TIRANTES,ETC,S OBRE APOIOS(EXCLUSIVE ESTES)PARA CARGA DE COBERTURA DE FIBROCIMENTO OU METALICA,VAOS ATE 15M,CONSIDERANDO AS PERDAS E UMA DEMAO DE PINTURA ANTI | 5d | 2021-09-27 | 2021-10-01 | 258d | finish no earlier than 2021-10-01 | 5,727.15 |
| 147 | 1.11.8 | PLACA DE POLICARBONATO EM CRISTAL COMPACTO,COM ESPESSURA DE 6MM.FORNECIMENTO E COLOCACAO | 4d | 2021-10-04 | 2021-10-07 | 254d | finish no earlier than 2021-10-07 | 7,205.19 |

| ID | WBS | Task | Duration | Start | Finish | Total slack | Constraint | Cost |
| --- | --- | --- | --- | --- | --- | --- | --- | --- |
| 148 | 1.12 | **CLIMATIZAÇÃO** | 30d | 2021-08-02 | 2021-09-10 | 273d |  | 316,076.27 |
| 149 | 1.12.1 | SISTEMA DE AR CONDICIONADO CENTRAL,TIPO "CHILLER",CONDENSACAO A AR,PARA UNIDADES MEDICAS ASSISTENCIAIS,NOS TERMOS DA NBR7256,ATE 50TR,INCLUSIVE PROJETO | 30d | 2021-08-02 | 2021-09-10 | 273d |  | 316,076.27 |
| 150 | 1.13 | GÁS, OXIGÊNIO, AR COMPRIMIDO | 1d | 2021-08-02 | 2021-08-02 | 302d |  |  |
| 151 | 1.14 | SPDA | 1d | 2021-08-02 | 2021-08-02 | 302d |  |  |
| 152 | 1.15 | INCÊNDIO | 1d | 2021-08-02 | 2021-08-02 | 302d |  |  |
| 153 | 1.16 | AQUECIMENTO SOLAR | 1d | 2021-08-02 | 2021-08-02 | 302d |  |  |
| 154 | 1.17 | CFTV | 1d | 2021-08-02 | 2021-08-02 | 302d |  |  |
| 155 | 1.18 | **PAISAGISMO** | 8d | 2022-09-05 | 2022-09-14 | 10d |  | 9,674.61 |
| 156 | 1.18.1 | Grama sintética Européia, em rolos, com fios de 28mm de comprimento, Flexigrass FLP PP 28mm ou similar, na cor verde, inclusive mão-de-obra especializada para execução de serviços, fornecimento e instalação de faixas de grama sintética branca para as dema | 8d | 2022-09-05 | 2022-09-14 | 10d | finish no earlier than 2022-09-14 | 1,452.33 |
| 157 | 1.18.2 | Plantio de arbusto para jardim, conforme Projeto FPJ.(desonerado) | 5d | 2022-09-05 | 2022-09-09 | 13d | finish no earlier than 2022-09-09 | 201.81 |
| 158 | 1.18.3 | Espécies vegetais com altura de (0,30 a 2,00)m, tipo Arbusto Dracaena Marginata (Dracena de Madagascar), Agave Attenuata (Agave Dragão), Agave Angustifolia (Piteira do Caribe), Arbusto Clusia Rosea (Clusia), CortadoriaSelloana (Pluma, Capim dos Pampas), D | 5d | 2022-09-05 | 2022-09-09 | 13d | finish no earlier than 2022-09-09 | 210 |
| 159 | 1.18.4 | Bancos para jardim com 14 réguas de madeira aparelhada, secção de (5,5 x 3,75)cm e comprimento de 2m, presas com parafusos de porca nos pés de ferro fundido, estes com 14Kg, barra de ferro ao centro do assentamento, inclusive espigão de fixação, 4 bases d | 5d | 2022-09-05 | 2022-09-09 | 13d | finish no earlier than 2022-09-09 | 4,050.97 |
| 160 | 1.18.5 | Protetor (gola) de árvore em ferro fundido nodular, nas dimensões de (1,00x1,00x0,60)m. Fornecimento.(desonerado) | 3d | 2022-09-05 | 2022-09-07 | 15d | finish no earlier than 2022-09-07 | 3,113.7 |
| 161 | 1.18.6 | Aterro com terra preta simples, para execução de gramados. | 3d | 2022-09-05 | 2022-09-07 | 15d | start no earlier than 2022-09-05 | 645.8 |
| 162 | 1.19 | **PROJETO EXECUTIVO** | 60d | 2021-08-12 | 2021-11-03 | 235d |  | 150,128.8 |
| 163 | 1.19.1 | PROJETO EXECUTIVO DE ARQUITETURA PARA PREDIOS HOSPITALARES ACIMA DE 4.000M2,INCLUSIVE PROJETO BASICO,APRESENTADO EM AUTOCAD NO PADROES DA CONTRATANTE,INCLUSIVE AS LEGALIZACOES PERTINENTES,COORDENACAO E COMPATIBILIZACAO COM OS PROJETOS COMPLEMENTARES | 60d | 2021-08-12 | 2021-11-03 | 235d | finish no earlier than 2021-11-03 | 150,128.8 |
| 164 | 1.20 | **LIMPEZA FINAL DE OBRA** | 10d | 2022-09-15 | 2022-09-28 | 0d |  | 20,877.65 |
| 165 | 1.20.1 | LIMPEZA DE APARELHOS SANITARIOS,INCLUSIVE METAIS | 10d | 2022-09-15 | 2022-09-28 | 0d | finish no earlier than 2022-09-28 | 548.27 |
| 166 | 1.20.2 | LIMPEZA DE PAINEIS DE ALUMINIO | 5d | 2022-09-15 | 2022-09-21 | 5d | finish no earlier than 2022-09-21 | 402.11 |
| 167 | 1.20.3 | LIMPEZA DE PAREDES REVESTIDAS DE CERAMICAS OU AZULEJOS | 10d | 2022-09-15 | 2022-09-28 | 0d | finish no earlier than 2022-09-28 | 3,918.6 |
| 168 | 1.20.4 | LIMPEZA DE PISOS CERAMICO,MARMORE OU GRANITO (SEM POLIMENTO) | 10d | 2022-09-15 | 2022-09-28 | 0d | finish no earlier than 2022-09-28 | 14,763.79 |
| 169 | 1.20.5 | LIMPEZA DE VIDROS,FEITA NOS DOIS LADOS,CONTADO UM LADO | 10d | 2022-09-15 | 2022-09-28 | 0d | finish no earlier than 2022-09-28 | 1,244.88 |
| 170 | 1.21 | **CANTEIRO DE OBRAS** | 20d | 2021-08-02 | 2021-08-27 | 283d |  | 73,167.95 |
| 171 | 1.21.1 | Galpão de canteiro de obras, para oficina e/ou depósito, inclusive o madeiramento, a cobertura de telha ondulada de fibrocimento, sem amianto, de 6mm de espessura, preparo do terreno e piso cimentado. | 20d | 2021-08-02 | 2021-08-27 | 283d |  | 73,167.95 |

| ID | WBS | Task | Duration | Start | Finish | Total slack | Cost |
| --- | --- | --- | --- | --- | --- | --- | --- |
| 172 | 1.22 | **ADMINISTRAÇÃO LOCAL** | 303d | 2021-08-02 | 2022-09-28 | 0d | 450,751.5 |
| 173 | 1.22.1 | ADMINISTRAÇÃO LOCAL | 303d | 2021-08-02 | 2022-09-28 | 0d | 450,751.5 |
